# Home Construction

Schedule from Primavera P6, 2018-10-09 to 2019-01-22, data date 2018-10-09, costs in USD.

## Calendars

- Calendar 1: Mon off; Tue-Sat 09:00-14:00, 15:00-19:00; Sun off.

## Resources

| Resource | Group | Unit | Rate |
| --- | --- | --- | --- |
| Daniel Muller | labor |  | 55 |
| Land Surveyor | labor |  | 65 |
| Excavator | labor |  | 70 |
| Process Operations | labor |  |  |
| Laborer Construction | labor |  | 18 |
| Ironworker | labor |  | 49 |
| Finish Carpenter | labor |  | 52 |
| Concrete | material | CY | 10 |
| Mason | labor |  | 10 |
| Plumber | labor |  | 58 |
| Finishes & Fit-out Subcontractor | labor |  | 49 |
| Richard Collins | labor |  | 40 |
| Electrician | labor |  | 52 |
| Glass & Glazing Subcontractor | labor |  | 70 |
| Landscaping Subcontractor | labor |  | 72 |

## Schedule

| ID | WBS | Activity | Type | Duration | Start | Finish | Predecessors | Total float | Free float | Resources | Cost |
| --- | --- | --- | --- | --- | --- | --- | --- | --- | --- | --- | --- |
| A1000 |  | Project Start | milestone | 0d | 2018-10-09 | 2018-10-09 |  | 76d | 0d |  |  |
| A1010 |  | Project Management | level of effort | 85d | 2018-10-09 | 2019-01-22 | A1000 SS | 0d |  | Daniel Muller [680 h] | 37,400 |
| A1020 |  | Project Complete | milestone | 0d | 2019-01-22 | 2019-01-22 | A1010 FF, A1170, A1190, A1230, A1260 | 0d |  |  |  |
|  | 1 | **Grading** |  |  | 2018-10-09 | 2018-10-18 |  |  |  |  |  |
| A1030 |  | Survey and mark out site |  | 3d | 2018-10-09 | 2018-10-11 | A1000 SS | 76d | 0d | Land Surveyor [24 h] | 1,560 |
| A1040 |  | Site Demarcation |  | 1d | 2018-10-11 | 2018-10-12 | A1030 | 76d | 0d | Land Surveyor [8 h] | 520 |
| A1050 |  | Excavation | resource dependent | 3d | 2018-10-12 | 2018-10-17 | A1040 | 76d | 0d | Excavator [21 h] | 1,470 |
| A1060 |  | Grade Site |  | 2d | 2018-10-17 | 2018-10-18 | A1050 | 76d |  | Process Operations [16 h] |  |
|  | 2 | **Foundation** |  |  | 2018-10-09 | 2018-10-24 |  |  |  |  |  |
| A1070 |  | Laying of Foundation |  | 4d | 2018-10-09 | 2018-10-12 |  | 0d |  | Laborer Construction [32 h]; Ironworker [32 h]; Finish Carpenter [32 h]; Concrete [32 CY]; Mason [32 h] | 4,448 |
| A1080 |  | Slab Plumbing |  | 7d | 2018-10-12 | 2018-10-20 | A1070 | 0d |  | Plumber [56 h] | 3,248 |
| A1090 |  | Pour and Float Slab Concrete |  | 2d | 2018-10-20 | 2018-10-24 | A1080 | 0d |  | Concrete [16 CY] | 160 |
|  | 3 | **Structure** |  |  | 2018-10-09 | 2019-01-22 |  |  |  |  |  |
|  | 1 | **Framing** |  |  | 2018-10-24 | 2018-12-25 |  |  |  |  |  |
| A1100 |  | Exterior Walls |  | 20d | 2018-10-24 | 2018-11-17 | A1090 | 0d |  | Mason [160 h]; Finishes & Fit-out Subcontractor [160 h] | 1,600 |
| A1110 |  | Interior Walls |  | 25d | 2018-11-17 | 2018-12-19 | A1100 | 27d |  | Mason [200 h]; Finishes & Fit-out Subcontractor [200 h] | 2,000 |
| A1120 |  | Exterior Cladding |  | 30d | 2018-11-17 | 2018-12-25 | A1100 | 0d |  | Finishes & Fit-out Subcontractor [240 h]; Mason [240 h] | 2,400 |
|  | 2 | **Roof** |  |  | 2018-11-17 | 2018-12-22 |  |  |  |  |  |
| A1130 |  | Truss Placing |  | 15d | 2018-11-17 | 2018-12-06 | A1100 | 19d | 0d | Ironworker [120 h] | 5,880 |
| A1140 |  | Roof Sheeting |  | 10d | 2018-12-06 | 2018-12-19 | A1130 | 19d | 0d | Laborer Construction [80 h] | 1,440 |
| A1150 |  | Place Paper and Shingles |  | 3d | 2018-12-19 | 2018-12-22 | A1140 | 19d | 0d | Laborer Construction [24 h] | 432 |
|  | 3 | **Interior** |  |  | 2018-10-09 | 2018-12-28 |  |  |  |  |  |
|  | 1 | **Mechnical** |  |  | 2018-12-22 | 2018-12-28 |  |  |  |  |  |
| A1160 |  | HVAC Ducting |  | 3d | 2018-12-22 | 2018-12-26 | A1150 | 19d | 0d | Richard Collins [24 h] | 960 |
| A1170 |  | Install HVAC Unit |  | 2d | 2018-12-26 | 2018-12-28 | A1160 | 19d |  | Richard Collins [16 h] | 640 |

| ID | WBS | Activity | Duration | Start | Finish | Predecessors | Total float | Free float | Resources | Cost |
| --- | --- | --- | --- | --- | --- | --- | --- | --- | --- | --- |
|  | 2 | **Electrical** |  | 2018-11-17 | 2018-12-01 |  |  |  |  |  |
| A1180 |  | Breaker Box and Rough Wire | 5d | 2018-11-17 | 2018-11-23 | A1100 | 40d | 0d | Electrician [40 h] | 2,080 |
| A1190 |  | Finish Wiring | 7d | 2018-11-23 | 2018-12-01 | A1180 | 40d |  | Electrician [56 h] | 2,912 |
|  | 3 | **Plumbing** |  | 2018-11-17 | 2018-11-30 |  |  |  |  |  |
| A1200 |  | Install Rough plumbing lines | 10d | 2018-11-17 | 2018-11-30 | A1100 | 28d | 0d | Plumber [80 h] | 4,640 |
|  | 4 | **Decor** |  | 2018-10-09 | 2018-12-18 |  |  |  |  |  |
| A1230 |  | Kitchen Cabinets | 10d | 2018-10-09 | 2018-10-19 |  | 75d |  | Finish Carpenter [80 h] | 4,160 |
| A1210 |  | Placing Doors | 8d | 2018-11-30 | 2018-12-11 | A1200 | 28d | 0d | Finish Carpenter [64 h] | 3,328 |
| A1220 |  | Door Placings and Baseboards | 6d | 2018-12-11 | 2018-12-18 | A1210 | 28d |  | Finish Carpenter [48 h] | 2,496 |
|  | 5 | **Exterior** |  | 2018-12-26 | 2019-01-16 |  |  |  |  |  |
| A1240 |  | Place Window | 12d | 2018-12-26 | 2019-01-09 | A1120 | 0d |  | Glass & Glazing Subcontractor [96 h]; Finish Carpenter [96 h] | 4,992 |
| A1250 |  | Window Sidings | 5d | 2019-01-09 | 2019-01-16 | A1240 | 0d |  | Finish Carpenter [40 h] | 2,080 |
|  | 4 | **Landscaping** |  | 2019-01-16 | 2019-01-22 |  |  |  |  |  |
| A1260 |  | Tree Plantings | 5d | 2019-01-16 | 2019-01-22 | A1250 | 0d |  | Landscaping Subcontractor [40 h] |  |

## Risks

| ID | Risk | Status |
| --- | --- | --- |
| RISK1 | Non availability of masonry crew | RS_Propose |
| RISK2 | Non availability of roof sheeting manpower | RS_Propose |

## Issues

| Issue | Status | Raised |
| --- | --- | --- |
| Start Date Variance (days) is 0 on WBS: CD00720 | IS_Open | 2018-10-09 |
| Start Date Variance (days) is 0 on WBS: CD00720.1 | IS_Open | 2018-10-09 |
| Start Date Variance (days) is 0 on WBS: CD00720.2 | IS_Open | 2018-10-09 |
| Start Date Variance (days) is 0 on WBS: CD00720.3 | IS_Open | 2018-10-09 |
| Start Date Variance (days) is 0 on WBS: CD00720.3.1 | IS_Open | 2018-10-09 |
| Start Date Variance (days) is 0 on WBS: CD00720.3.2 | IS_Open | 2018-10-09 |
| Start Date Variance (days) is 0 on WBS: CD00720.3.3 | IS_Open | 2018-10-09 |
| Start Date Variance (days) is 0 on WBS: CD00720.3.3.1 | IS_Open | 2018-10-09 |
| Start Date Variance (days) is 0 on WBS: CD00720.3.3.2 | IS_Open | 2018-10-09 |
| Start Date Variance (days) is 0 on WBS: CD00720.3.3.3 | IS_Open | 2018-10-09 |
| Start Date Variance (days) is 0 on WBS: CD00720.3.3.4 | IS_Open | 2018-10-09 |
| Start Date Variance (days) is 0 on WBS: CD00720.3.5 | IS_Open | 2018-10-09 |
| Start Date Variance (days) is 0 on WBS: CD00720.3.4 | IS_Open | 2018-10-09 |
